# CAT

Schedule from Planner, 2006-01-02 to 2008-11-07.
CEA
Phase: Étude de besoins

## Calendars

- Défaut: Mon-Fri 08:00-12:00, 13:00-17:00; Sat-Sun off.

## Schedule

| ID | Task | Duration | Start | Finish | Predecessors | Constraint | Work |
| --- | --- | --- | --- | --- | --- | --- | --- |
| 1 | Evaluation de besoins | 108d | 2006-01-02 | 2006-05-31 |  | must start on 2006-01-02 | 960h |
| 2 | Infrastructure générique | 108d | 2006-06-01 | 2006-10-30 | 1 | must start on 2006-06-01 | 24h |
| 3 | Interprétation abstraite | 108d | 2006-10-02 | 2007-02-28 | 4SS, 2 | must start on 2006-10-02 | 96h |
| 4 | Preuve automatique | 180d | 2006-10-31 | 2007-07-09 | 5, 2 |  | 8h |
| 5 | Spécialisation | 108d | 2006-05-01 | 2006-09-27 | 2 | must start on 2006-05-01 | 48h |
| 6 | Preuve à la Hoare | 252d | 2006-10-31 | 2007-10-17 | 2 |  | 40h |
| 7 | Langage de propriété | 216d | 2006-01-02 | 2006-10-30 | 2 | must start on 2006-01-02 | 48h |
| 8 | methodologie de vérification | 216d | 2007-03-01 | 2007-12-27 | 3, 5, 7 |  |  |
| 9 | Qualification | 216d | 2008-01-02 | 2008-10-29 | 4, 3, 7, 6, 5 | must start on 2008-01-02 | 2024h |
| 10 | Évaluation | 180d | 2008-03-03 | 2008-11-07 | 8 | must start on 2008-03-01 | 8h |
